# gantt2

Schedule from MS Project, 2017-03-02 to 2017-06-22, status date 2017-05-27, costs in €, A marks actual dates.

## Calendars

- Standard: Mon-Fri 08:00-12:00, 13:00-17:00; Sat-Sun off. Exceptions (off unless hours are given): 2017-04-30 08:00-12:00, 13:00-17:00, 2017-06-10 08:00-12:00, 13:00-17:00, 2017-06-18 08:00-12:00, 13:00-17:00.

## Resources

| Resource | Rate |
| --- | --- |
| Elin | 10 |
| Simone | 10 |
| Marion | 10 |
| Mikk | 10 |
| Miguel | 10 |
| Material: |  |
| LilyPad Arduino | 5 |
| UV sensor | 28.3 |
| Leds indicators | 1.2 |
| Solar panel |  |
| Silicon |  |
| magnet |  |
| case (waterproof) |  |
| Miguek |  |
| Mario, |  |

## Schedule

| ID | WBS | Task | Type | Duration | Start | Finish | Predecessors | Complete | Remaining | Actual finish | Baseline start | Baseline finish | Baseline duration | Total slack | Deadline | Resources | Work | Actual work | Cost | Baseline cost | Actual cost |
| --- | --- | --- | --- | --- | --- | --- | --- | --- | --- | --- | --- | --- | --- | --- | --- | --- | --- | --- | --- | --- | --- |
| 1 | 1 | **UV Meter** |  | 84d? | 2017-03-02 A | 2017-06-22 |  | 98% | 2d? |  | 2017-03-02 | 2017-06-22 | 81d | 0d |  |  | 1358.8h | 1234.8h | 13,622.5 | 11,770.5 | 12,375.6 |
| 2 | 1.1 | **Project studies** |  | 1d? | 2017-03-02 A | 2017-03-02 |  | 100% |  | 2017-04-03 | 2017-03-02 | 2017-03-02 | 1d? |  |  |  | 187.6h | 187.6h | 1,876 | 1,800 | 1,876 |
| 3 | 1.1.1 | Analyze of customers needs | manual | 1d | 2017-03-02 A | 2017-03-02 A |  | 100% |  |  | 2017-03-02 | 2017-03-02 | 1d |  |  | Simone [10%]; Marion [50%]; Elin [20%] | 8h | 8h | 80 | 80 | 80 |
| 4 | 1.1.2 | Analyze the concurrency (state of art WIKI page) | manual | 1d | 2017-03-02 A | 2017-03-02 A |  | 100% |  |  | 2017-03-02 | 2017-03-02 | 1d |  |  | Mikk | 8h | 8h | 80 | 80 | 80 |
| 5 | 1.1.3 | Marketing Brief | manual | 3d | 2017-03-03 A | 2017-03-07 A | 4 | 100% |  |  | 2017-03-03 | 2017-03-07 | 3d |  |  | Miguel [50%]; Marion [50%] | 24h | 24h | 240 | 240 | 240 |
| 6 | 1.1.4 | System diagrams & structural drafts (Black Box) | manual | 4d | 2017-03-08 A | 2017-03-13 A | 5 | 100% |  |  | 2017-03-08 | 2017-03-13 | 4d |  | 2017-03-13 | Elin [40%]; Mikk [50%] | 16h | 16h | 160 | 160 | 160 |
| 7 | 1.1.5 | System schematics & structural drawings (Cardboard prototype + 3D software) | manual | 9d | 2017-03-14 A | 2017-03-24 A |  | 100% |  |  | 2017-03-14 | 2017-03-24 | 9d |  | 2017-03-27 | Marion [50%]; Miguel [50%] | 72h | 72h | 720 | 720 | 720 |
| 8 | 1.1.6 | milestone schematics | milestone | 0d | 2017-03-24 A | 2017-03-24 A | 7 | 100% |  |  |  |  |  |  | 2017-03-27 |  |  |  |  |  |  |
| 9 | 1.1.7 | Packaging research | manual | 2d | 2017-03-27 A | 2017-03-28 A | 7 | 100% |  |  |  |  |  |  |  | Marion [50%] | 8h | 8h | 80 |  | 80 |
| 10 | 1.1.8 | Legal research (Ethic) | manual | 2d | 2017-03-14 A | 2017-03-15 A | 7SS | 100% |  |  | 2017-03-14 | 2017-03-15 | 2d |  |  | Simone [50%]; Elin [50%] | 15.6h | 15.6h | 156 | 160 | 156 |
| 11 | 1.1.9 | Research of materials | manual | 3d | 2017-03-27 A | 2017-03-29 A |  | 100% |  |  | 2017-03-27 | 2017-03-29 | 3d |  |  | Elin [50%]; Mikk [50%] | 12h | 12h | 120 | 120 | 120 |
| 12 | 1.1.10 | Make a provisional budget | manual | 3d | 2017-03-30 A | 2017-04-03 A | 11 | 100% |  |  | 2017-03-30 | 2017-04-03 | 3d |  |  | Mikk | 24h | 24h | 240 | 240 | 240 |
| 13 | 1.2 | Interim report: wiki page | manual | 28d | 2017-03-02 A | 2017-04-10 A | 3SS | 100% |  |  | 2017-03-02 | 2017-04-10 | 28d |  |  | Elin [50%]; Simone [30%]; Marion [40%] | 179.2h | 179.2h | 1,792 | 1,792 | 1,792 |
| 14 | 1.3 | Upload Interim presentation: wiki page | manual | 2d | 2017-04-13 A | 2017-04-14 A | 13 | 100% |  |  | 2017-04-13 | 2017-04-14 | 2d |  |  | Marion [50%] | 8h | 8h | 80 | 80 | 80 |
| 15 | 1.4 | Interim presentation | manual | 3d | 2017-04-13 A | 2017-04-17 A |  | 100% |  |  | 2017-04-13 | 2017-04-17 | 3d |  |  | Elin [80%] | 19.2h | 19.2h | 192 | 192 | 192 |
| 16 | 1.5 | Refined Interim Report (Wiki) | manual | 7d | 2017-04-21 A | 2017-04-29 A |  | 100% |  |  | 2017-04-21 | 2017-04-29 | 7d |  |  | Marion [50%]; Elin [10%] | 33.6h | 33.6h | 336 | 336 | 336 |
| 17 | 1.6 | **Material** |  | 16d | 2017-04-01 A | 2017-04-24 A |  | 100% |  |  | 2017-04-01 | 2017-04-24 | 16d |  |  |  | 118.4h | 118.4h | 1,184 | 1,200 | 1,184 |
| 18 | 1.6.1 | Make a list of material | manual | 2d | 2017-04-01 A | 2017-04-03 A | 12 | 100% |  |  | 2017-04-01 | 2017-04-03 | 2d |  | 2017-04-03 | Marion [40%]; Miguel [30%]; Mikk [30%] | 12.8h | 12.8h | 128 | 144 | 128 |
| 19 | 1.6.2 | Research of suppliers (materials: plastic, silicon) | manual | 14d | 2017-04-04 A | 2017-04-21 A | 18 | 100% |  |  | 2017-04-04 | 2017-04-21 | 14d |  |  | Mikk [40%] | 44.8h | 44.8h | 448 | 448 | 448 |
| 20 | 1.6.3 | Research of suppliers (industrial: tools) | manual | 14d | 2017-04-04 A | 2017-04-21 A | 19SS | 100% |  |  | 2017-04-04 | 2017-04-21 | 14d |  |  | Mikk [40%] | 44.8h | 44.8h | 448 | 448 | 448 |
| 21 | 1.6.4 | EASTER HOLIDAYS | manual | 7d | 2017-04-08 A | 2017-04-17 A |  | 100% |  |  | 2017-04-08 | 2017-04-17 | 7d |  |  |  |  |  |  |  |  |
| 22 | 1.6.5 | Validation (complete the list on wiki) | manual | 2d | 2017-04-22 A | 2017-04-24 A |  | 100% |  |  | 2017-04-22 | 2017-04-24 | 2d |  | 2017-04-24 | Miguel [20%]; Elin [20%]; Marion [20%]; Mikk [20%]; Simone [20%] | 16h | 16h | 160 | 160 | 160 |
| 23 | 1.7 | **Development** |  | 24d | 2017-05-03 A | 2017-06-05 |  | 94% | 1.53d |  | 2017-05-03 | 2017-06-05 | 24d | 0d |  |  | 268.8h | 194.56h | 2,722.5 | 1,570.5 | 1,973.2 |
| 24 | 1.7.1 | Creation of prototypes | manual | 17d | 2017-05-03 A | 2017-05-25 |  | 80% | 3.4d |  | 2017-05-03 | 2017-05-25 | 17d |  |  | Miguel [50%]; Leds indicators; LilyPad Arduino; UV sensor; Elin [20%]; Marion [20%]; Simone [20%]; Mikk [60%] | 231.2h | 184.96h | 2,346.5 | 1,122.5 | 1,877.2 |
| 25 | 1.7.2 | Packaging plans | manual | 2d | 2017-05-26 A | 2017-05-29 A | 24 | 100% |  |  |  |  |  |  |  | Marion [60%] | 9.6h | 9.6h | 96 |  | 96 |
| 26 | 1.7.3 | STUDENT WEEK | manual | 7d | 2017-05-06 A | 2017-05-14 A |  | 100% |  |  | 2017-05-06 | 2017-05-14 | 7d |  |  |  |  |  |  |  |  |

| ID | WBS | Task | Type | Duration | Start | Finish | Predecessors | Complete | Remaining | Baseline start | Baseline finish | Baseline duration | Total slack | Constraint | Deadline | Resources | Work | Actual work | Cost | Baseline cost | Actual cost |
| --- | --- | --- | --- | --- | --- | --- | --- | --- | --- | --- | --- | --- | --- | --- | --- | --- | --- | --- | --- | --- | --- |
| 27 | 1.7.4 | **Tests** |  | 7d | 2017-05-26 A | 2017-06-05 | 24 | 99% | 0.02d | 2017-05-26 | 2017-06-05 | 7d |  |  |  | Simone [50%] | 28h |  | 280 | 448 |  |
| 28 | 1.7.4.1 | Wearability | manual | 7d | 2017-05-26 A | 2017-06-05 A |  | 100% |  | 2017-05-26 | 2017-06-05 | 7d |  |  |  |  |  |  |  |  |  |
| 29 | 1.7.4.2 | Robustness | manual | 7d | 2017-05-26 A | 2017-06-05 A |  | 100% |  | 2017-05-26 | 2017-06-05 | 7d |  |  |  |  |  |  |  |  |  |
| 30 | 1.7.4.3 | UV radiation | manual | 7d | 2017-05-26 A | 2017-06-05 A |  | 100% |  | 2017-05-26 | 2017-06-05 | 7d |  |  |  |  |  |  |  |  |  |
| 31 | 1.7.4.4 | Water resistance | manual | 7d | 2017-05-26 A | 2017-06-05 A |  | 100% |  | 2017-05-26 | 2017-06-05 | 7d |  |  |  |  |  |  |  |  |  |
| 32 | 1.7.4.5 | Modification | manual | 1d | 2017-05-26 A | 2017-05-26 |  | 90% | 0.1d | 2017-05-26 | 2017-05-26 | 1d? |  |  |  |  |  |  |  |  |  |
| 33 | 1.8 | **Delivery** |  | 46d? | 2017-04-25 A | 2017-06-22 |  | 97% | 1.17d? | 2017-04-11 | 2017-06-22 | 53d | 0d |  |  |  | 544h | 494.24h | 5,440 | 4,800 | 4,942.4 |
| 34 | 1.8.1 | Make the final product | manual | 1d | 2017-05-30 A | 2017-05-30 |  | 60% | 0.4d | 2017-05-30 | 2017-05-30 | 1d |  |  |  | Miguel [80%] | 6.4h | 3.84h | 64 | 64 | 38.4 |
| 35 | 1.8.2 | Upload the functional tests results | manual | 4d | 2017-05-31 A | 2017-06-05 A |  | 100% |  | 2017-05-31 | 2017-06-05 | 4d |  |  |  | Mikk [30%]; Marion [30%] | 19.2h | 19.2h | 192 | 160 | 192 |
| 36 | 1.8.3 | Final report |  | 36d | 2017-04-29 A | 2017-06-15 | 13 | 95% | 1.8d | 2017-04-11 | 2017-06-16 | 49d | 6d |  |  | Simone [10%]; Elin [10%]; Marion [10%]; Miguel [10%]; Mikk [10%] | 242h | 234.8h | 2,420 | 3,920 | 2,348 |
| 37 | 1.8.4 | Video |  | 25d | 2017-04-30 A | 2017-06-01 A | 16 | 100% |  |  |  |  |  |  |  | Mikk [20%] | 40h | 40h | 400 |  | 400 |
| 38 | 1.8.5 | Leaflet |  | 24d | 2017-04-30 A | 2017-05-31 A | 16 | 100% |  |  |  |  |  |  |  | Marion [30%] | 57.6h | 57.6h | 576 |  | 576 |
| 39 | 1.8.6 | Poster |  | 25d | 2017-04-30 A | 2017-06-01 A | 16 | 100% |  |  |  |  |  |  |  | Miguel [20%] | 40h | 40h | 400 |  | 400 |
| 40 | 1.8.7 | Manual |  | 23d | 2017-04-30 A | 2017-05-30 A | 16 | 100% |  |  |  |  |  |  |  | Marion [20%] | 36.8h | 36.8h | 368 |  | 368 |
| 41 | 1.8.8 | Paper |  | 15d | 2017-04-30 A | 2017-05-18 A | 16 | 100% |  |  |  |  |  |  |  | Simone [10%] | 12h | 12h | 120 |  | 120 |
| 42 | 1.8.9 | Milestone Paper (ICL) | milestone | 0d | 2017-05-18 A | 2017-05-18 A | 41 | 100% |  |  |  |  |  |  | 2017-05-22 |  |  |  |  |  |  |
| 43 | 1.8.10 | Arduino code |  | 25d | 2017-04-25 A | 2017-05-26 A | 22 | 100% |  |  |  |  |  |  |  | Elin [20%] | 40h | 40h | 400 |  | 400 |
| 44 | 1.8.11 | Website |  | 25d | 2017-04-30 A | 2017-06-01 A | 16 | 100% |  |  |  |  |  |  |  | Miguel [5%] | 10h | 10h | 100 |  | 100 |
| 45 | 1.8.12 | Presentation |  | 4d | 2017-06-06 A | 2017-06-09 | 27 | 96% | 0.16d |  |  |  | 7d |  |  |  |  |  |  |  |  |
| 46 | 1.8.13 | Milestone final deliverables | milestone | 0d | 2017-06-18 | 2017-06-18 | 35, 45 |  |  | 2017-06-16 | 2017-06-16 | 0d | 0d | finish no earlier than 2017-06-18 | 2017-06-18 |  |  |  |  |  |  |
| 47 | 1.8.14 | Final Presentation and assessment | manual | 1d | 2017-06-22 | 2017-06-22 |  |  |  | 2017-06-22 | 2017-06-22 | 1d |  |  | 2017-06-22 | Elin; Marion; Miguel; Mikk; Simone | 40h |  | 400 | 400 |  |
| 48 | 1.8.15 | Update the wiki | manual | 1d? | 2017-04-25 | 2017-04-25 |  |  |  | 2017-04-11 | 2017-04-11 | 1d? |  |  |  |  |  |  |  |  |  |
| 49 | 1.8.16 | Hand in the prototype and manual | manual | 1d? | 2017-04-25 | 2017-04-25 |  |  |  | 2017-04-11 | 2017-04-11 | 1d? |  |  |  |  |  |  |  |  |  |
